# Start

Schedule from MS Project, 2014-04-07 to 2014-07-01, status date 2014-06-25, costs in Kč, A marks actual dates.
Řízení firmy
Encián
Projekt rekonstrukce zasedací místnosti 18 na školící počítačovou místnost a akce uvedení nového software na trh v roce 2014.

## Calendars

- Firemní: Mon-Fri 08:00-12:00, 13:00-17:00; Sat-Sun off. Exceptions (off unless hours are given): 2014-04-21 (Velikonoční pondělí), 2014-05-01 (Svátek práce), 2014-05-08 (Den vítězství).
- Rodiče: Mon-Fri 08:00-12:00, 13:00-17:00; Sat-Sun off. Exceptions (off unless hours are given): 2014-04-21 (Velikonoční pondělí), 2014-05-01 (Svátek práce), 2014-05-08 (Den vítězství), 2014-05-17 08:00-12:00, 13:00-17:00 (Pracovní sobota 17. 5. 2014), 2014-05-19 (Volné pondělí 19. 5. 2014).
- Koncepce: Mon-Fri 08:00-12:00, 13:00-19:00; Sat-Sun off. Exceptions (off unless hours are given): 2014-04-21 (Velikonoční pondělí), 2014-05-01 (Svátek práce), 2014-05-08 (Den vítězství).

## Resources

| Resource | Group | Unit | Rate | Cost per use | Notes |
| --- | --- | --- | --- | --- | --- |
| Sladká | RED |  | 150 |  |  |
| Kolínská | PRG |  | 200 |  |  |
| Novák | RED |  | 200 |  |  |
| údržbáři | P |  | 150 |  |  |
| Janda | ANA |  | 200 |  |  |
| Dvořák | KON |  | 200 |  |  |
| Benešová | DIS |  | 200 |  |  |
| Smetana | REK |  | 200 |  | Milan Smetana je na dlouhodobé zahraniční služební cestě do 13. 4. 2014, po níž bude zčásti vázán na jiném projektu, proto jeho maximální počet jednotek je následující: / ·do 13. 4. 2014: 0 %, / ·od 14. 4. 2014: 50 %. |
| malíři | V |  | 150 | 500 |  |
| zedníci | V |  | 150 | 500 |  |
| koberec |  | m2 | 200 |  |  |
| rozeslání pozvánky |  | ks | 15 | 100 |  |
| síťový kabel |  | m. | 5 |  |  |
| papír |  |  |  |  |  |
| toner |  |  |  |  |  |
| telefon |  |  |  |  |  |
| občerstvení |  |  |  |  |  |
| interní nákladový rozpočet |  |  |  |  |  |
| externí nákladový rozpočet |  |  |  |  |  |
| pracovní rozpočet |  |  | 200 |  |  |
| rozpočet síťových kabelů |  |  |  |  |  |

## Schedule

| ID | WBS | Task | Type | Duration | Start | Finish | Predecessors | Complete | Baseline start | Baseline finish | Baseline duration | Baseline 1 start | Baseline 1 finish | Total slack | Constraint | Deadline | Calendar | Resources | Work | Actual work | Cost | Baseline cost | Actual cost | Dlouhý název úkolu |
| --- | --- | --- | --- | --- | --- | --- | --- | --- | --- | --- | --- | --- | --- | --- | --- | --- | --- | --- | --- | --- | --- | --- | --- | --- |
| 1 | 1 | **rekonstrukce zasedací místnosti** |  | 27d | 2014-04-07 | 2014-05-16 |  |  | 2014-04-07 | 2014-05-16 | 27d | 2014-04-07 | 2014-05-16 | 0d |  |  |  | papír [0.1%]; telefon [0.1%]; toner [0.1%] | 182h | 182h | 890,065 | 950,664.96 | 890,065 |  |
| 2 | 1.1 | koncepce vybavení místnosti |  | 1w | 2014-04-07 A | 2014-04-10 A |  | 100% | 2014-04-07 | 2014-04-10 | 1w | 2014-04-07 | 2014-04-10 |  |  |  | Koncepce | Kolínská [50%]; údržbáři [50%] | 40h | 40h | 7,200 | 7,200 | 7,200 | 1.1 koncepce vybavení místnosti |
| 3 | 1.2 | rozpočet vybavení místnosti |  | 2d | 2014-04-09 A | 2014-04-10 A | 2SS+2d | 100% | 2014-04-09 | 2014-04-10 | 2d | 2014-04-09 | 2014-04-10 |  |  |  |  | Sladká | 16h | 16h | 2,400 | 2,400 | 2,400 | 1.2 rozpočet vybavení místnosti |
| 4 | 1.3 | schválení koncepce a rozpočtu vybavení |  | 1d | 2014-04-11 A | 2014-04-11 A | 2, 3 | 100% | 2014-04-11 | 2014-04-11 | 1d | 2014-04-11 | 2014-04-11 |  |  |  |  | Novák [25%] | 2h | 2h | 400 | 400 | 400 | 1.3 schválení koncepce a rozpočtu vybavení |
| 5 | 1.4 | výběr a objednání počítačů |  | 3d | 2014-04-14 A | 2014-04-23 A | 4 | 100% | 2014-04-14 | 2014-04-23 | 3d | 2014-04-14 | 2014-04-23 |  |  |  |  | Kolínská [25%] | 6h | 6h | 1,200 | 1,200 | 1,200 | 1.4 výběr a objednání počítačů |
| 6 | 1.5 | dodání počítačů a dataprojektoru |  | 1d | 2014-05-14 A | 2014-05-14 A | 5FS+9d | 100% | 2014-05-07 | 2014-05-08 | 1d | 2014-05-07 | 2014-05-08 |  | start no earlier than 2014-05-12 |  |  | Kolínská [25%] | 2h | 2h | 608,183 | 678,183 | 608,183 | 1.5 dodání počítačů a dataprojektoru |
| 7 | 1.6 | zazdění dveří |  | 1d | 2014-04-14 A | 2014-04-14 A | 4 | 100% | 2014-04-14 | 2014-04-15 | 2d | 2014-04-14 | 2014-04-14 |  |  |  |  | zedníci [50%] | 4h | 4h | 850 | 1,450 | 850 | 1.6 zazdění dveří |
| 8 | 1.7 | podhled |  | 2d | 2014-04-15 A | 2014-04-16 A | 7 | 100% | 2014-04-16 | 2014-04-17 | 2d | 2014-04-15 | 2014-04-16 |  |  |  |  | údržbáři [200%] | 32h | 32h | 11,200 | 12,200 | 11,200 | 1.7 podhled |
| 9 | 1.8 | elektroinstalace |  | 1d | 2014-04-17 A | 2014-04-17 A | 8 | 100% | 2014-04-18 | 2014-04-18 | 1d | 2014-04-17 | 2014-04-17 |  |  |  |  | údržbáři [200%] | 16h | 16h | 3,600 | 3,600 | 3,600 | 1.8 elektroinstalace |
| 10 | 1.9 | vymalování |  | 1d | 2014-04-18 A | 2014-04-18 A | 9 | 100% | 2014-04-22 | 2014-04-22 | 1d | 2014-04-18 | 2014-04-18 |  | finish no later than 2014-04-30 |  |  | malíři [200%] | 16h | 16h | 3,400 | 3,400 | 3,400 | 1.9 vymalování |
| 11 | 1.10 | položení koberce |  | 1d | 2014-05-05 A | 2014-05-05 A | 10 | 100% | 2014-05-05 | 2014-05-05 | 1d | 2014-05-05 | 2014-05-05 |  | as late as possible | 2014-05-05 |  | údržbáři [50%]; koberec [92 m2] | 4h | 4h | 19,200 | 19,200 | 19,200 | 1.10 položení koberce |
| 12 | 1.11 | výběr a objednání nábytku |  | 2d | 2014-04-14 A | 2014-04-15 A | 4 | 100% | 2014-04-14 | 2014-04-15 | 2d | 2014-04-14 | 2014-04-15 |  |  |  |  | Sladká [50%] | 12h | 12h | 2,000 | 2,000 | 2,000 | 1.11 výběr a objednání nábytku |
| 13 | 1.12 | dodání a montáž nábytku |  | 1d | 2014-05-09 A | 2014-05-09 A | 11, 12FS+14d | 100% | 2014-05-09 | 2014-05-09 | 1d | 2014-05-09 | 2014-05-09 |  |  |  |  |  |  |  | 222,907 | 211,907 | 222,907 | 1.12 dodání a montáž nábytku |
| 14 | 1.13 | vyvětrání |  | 5ed | 2014-05-09 A | 2014-05-14 A | 13 | 100% | 2014-05-09 | 2014-05-14 | 5ed | 2014-05-09 | 2014-05-14 |  |  |  |  |  |  |  |  |  |  | 1.13 vyvětrání |
| 15 | 1.14 | instalace sítě |  | 1d | 2014-05-15 A | 2014-05-15 A | 14 | 100% | 2014-05-15 | 2014-05-15 | 1d | 2014-05-15 | 2014-05-15 |  |  |  |  | Kolínská; síťový kabel [45 m.] | 8h | 8h | 1,825 | 1,825 | 1,825 | 1.14 instalace sítě |
| 16 | 1.15 | instalace počítačů |  | 1d | 2014-05-16 A | 2014-05-16 A | 15, 6 | 100% | 2014-05-16 | 2014-05-16 | 1d | 2014-05-16 | 2014-05-16 |  |  |  |  | Kolínská | 8h | 8h | 1,600 | 1,600 | 1,600 | 1.15 instalace počítačů |
| 17 | 1.16 | příprava rezervačního software |  | 5d | 2014-04-07 A | 2014-04-11 A |  | 100% | 2014-04-07 | 2014-04-11 | 5d | 2014-04-07 | 2014-04-11 |  |  |  |  | Kolínská [25%]; Janda [25%] | 16h | 16h | 3,200 | 3,200 | 3,200 | 1.16 příprava rezervačního software |
| 18 | 1.17 | zahájení provozu místnosti | milestone | 0d | 2014-05-16 A | 2014-05-16 A | 17, 16 | 100% | 2014-05-16 | 2014-05-16 | 0d | 2014-05-16 | 2014-05-16 |  |  |  |  |  |  |  |  |  |  | 1.17 zahájení provozu místnosti |
| 19 | 2 | **akce uvedení nového software na trh** |  | 47d | 2014-04-17 | 2014-07-01 |  |  | 2014-04-14 | 2014-06-25 | 50d | 2014-04-14 | 2014-06-25 | 0d |  |  |  | papír [0.1%]; telefon [0.1%]; toner [0.1%] | 68h | 68h | 29,400 | 29,400 | 29,400 |  |
| 20 | 2.1 | webová prezentace uvedení |  | 2d | 2014-05-17 A | 2014-05-20 A | 18 | 100% | 2014-05-17 | 2014-05-20 | 2d | 2014-05-17 | 2014-05-20 |  |  |  |  | Kolínská [50%] | 8h | 8h | 1,600 | 1,600 | 1,600 | 2.1 webová prezentace uvedení |
| 21 | 2.2 | přihlašování na uvedení |  | 15ed | 2014-06-03 A | 2014-06-18 A | 20FS+2w | 100% | 2014-06-03 | 2014-06-18 | 15ed | 2014-06-03 | 2014-06-18 |  |  |  |  |  |  |  |  |  |  | 2.2 přihlašování na uvedení |
| 22 | 2.3 | objednání občerstvení |  | 1d | 2014-04-21 A | 2014-04-22 A | 4 | 100% | 2014-04-14 | 2014-04-14 | 1d | 2014-04-14 | 2014-04-14 |  |  |  |  | Sladká [25%] | 2h | 2h | 300 | 300 | 300 | 2.3 objednání občerstvení |
| 23 | 2.4 | návrh letáků k uvedení |  | 2d | 2014-04-17 A | 2014-04-18 A | 4 | 100% | 2014-04-17 | 2014-04-18 | 2d | 2014-04-17 | 2014-04-18 |  |  |  |  | Smetana [50%] | 8h | 8h | 1,600 | 1,600 | 1,600 | 2.4 návrh letáků k uvedení |
| 24 | 2.5 | dodání letáků | milestone | 0d | 2014-04-18 A | 2014-04-18 A | 23 | 100% | 2014-04-18 | 2014-04-18 | 0d | 2014-04-18 | 2014-04-18 |  |  |  |  |  |  |  | 3,200 | 3,200 | 3,200 | 2.5 dodání letáků |
| 25 | 2.6 | rozeslání pozvánek |  | 2d | 2014-04-23 A | 2014-04-24 A | 24 | 100% | 2014-04-23 | 2014-04-24 | 2d | 2014-04-23 | 2014-04-24 |  |  |  |  | Sladká; rozeslání pozvánky [100 ks] | 16h | 16h | 4,000 | 4,000 | 4,000 | 2.6 rozeslání pozvánek |
| 26 | 2.7 | výběr, objednání propagačních materiálů |  | 1d | 2014-04-22 A | 2014-04-22 A | 4 | 100% | 2014-04-22 | 2014-04-22 | 1d | 2014-04-22 | 2014-04-22 |  |  |  |  | Sladká | 8h | 8h | 1,200 | 1,200 | 1,200 | 2.7 výběr, objednání propagačních materiálů |
| 27 | 2.8 | dodání propagačních materiálů | milestone | 0d | 2014-04-22 A | 2014-04-22 A | 26 | 100% | 2014-04-22 | 2014-04-22 | 0d | 2014-04-22 | 2014-04-22 |  |  |  |  |  |  |  | 6,800 | 6,800 | 6,800 | 2.8 dodání propagačních materiálů |
| 28 | 2.9 | milník přípravy akce uvedení | milestone | 0d | 2014-04-29 A | 2014-04-29 A | 27FS+5d, 23FS+3d | 100% | 2014-04-29 | 2014-04-29 | 0d | 2014-04-29 | 2014-04-29 |  |  |  |  |  |  |  |  |  |  | 2.9 milník přípravy akce uvedení |
| 29 | 2.10 | uzávěrka přihlašování | milestone | 0d | 2014-06-18 A | 2014-06-18 A | 21 | 100% | 2014-06-18 | 2014-06-18 | 0d | 2014-06-18 | 2014-06-18 |  |  |  |  |  |  |  |  |  |  | 2.10 uzávěrka přihlašování |
| 30 | 2.11 | průběh akce uvedení software |  | 1d | 2014-06-24 A | 2014-06-24 A | 29FS+2d, 28FS+1w, 22FS+10d | 100% | 2014-06-24 | 2014-06-24 | 1d | 2014-06-24 | 2014-06-24 |  | must start on 2014-06-24 |  |  | Novák; Kolínská; Sladká | 24h | 24h | 9,400 | 9,400 | 9,400 | 2.11 průběh akce uvedení software |
| 31 | 2.12 | tisková zpráva o uvedení |  | 1d | 2014-06-25 A | 2014-06-25 A | 30, 24 | 100% | 2014-06-25 | 2014-06-25 | 1d | 2014-06-25 | 2014-06-25 |  |  |  |  | Novák [25%] | 2h | 2h | 400 | 400 | 400 | 2.12 tisková zpráva o uvedení |

| ID | WBS | Task | Duration | Start | Finish | Complete | Baseline start | Baseline finish | Baseline duration | Baseline 1 start | Baseline 1 finish | Total slack | Constraint | Calendar | Resources | Work | Actual work | Cost | Baseline cost | Actual cost | Dlouhý název úkolu |
| --- | --- | --- | --- | --- | --- | --- | --- | --- | --- | --- | --- | --- | --- | --- | --- | --- | --- | --- | --- | --- | --- |
| 32 | 3 | **porada vedení** | 37.88d | 2014-04-11 | 2014-06-06 |  | 2014-04-11 | 2014-06-06 | 37.88d | 2014-04-11 | 2014-06-06 | 0d |  | Rodiče |  | 40h | 40h | 7,850 | 7,850 | 7,850 |  |
| 33 | 3.1 | porada vedení 1 | 1d | 2014-04-11 A | 2014-04-11 A | 100% | 2014-04-11 | 2014-04-11 | 1d | 2014-04-11 | 2014-04-11 |  | start no earlier than 2014-04-11 | Rodiče | Novák [25%]; Sladká [25%]; Dvořák [25%]; Benešová [25%]; Janda [25%]; Kolínská [25%] | 12h | 12h | 2,350 | 2,350 | 2,350 | 3.1 porada vedení 1 |
| 34 | 3.2 | porada vedení 2 | 1d | 2014-05-05 A | 2014-05-05 A | 100% | 2014-05-05 | 2014-05-05 | 1d | 2014-05-05 | 2014-05-05 |  | start no earlier than 2014-05-02 | Rodiče | Novák [25%]; Sladká [25%]; Dvořák [25%]; Smetana [25%]; Benešová [25%]; Janda [25%]; Kolínská [25%] | 14h | 14h | 2,750 | 2,750 | 2,750 | 3.2 porada vedení 2 |
| 35 | 3.3 | porada vedení 3 | 1d | 2014-06-06 A | 2014-06-06 A | 100% | 2014-06-06 | 2014-06-06 | 1d | 2014-06-06 | 2014-06-06 |  | start no earlier than 2014-06-06 | Rodiče | Novák [25%]; Sladká [25%]; Dvořák [25%]; Smetana [25%]; Benešová [25%]; Janda [25%]; Kolínská [25%] | 14h | 14h | 2,750 | 2,750 | 2,750 | 3.3 porada vedení 3 |
